# Controlsx

Schedule from MS Project, 2008-08-20 to 2008-10-31.
Fermi

## Calendars

- Standard: Mon-Fri 08:00-12:00, 13:00-17:00; Sat-Sun off.

## Resources

| Resource |
| --- |
| Patrick |
| Lackey |
| Briegel |
| Nicklaus |
| Hendricks |
| Schumann |
| Neswold |
| Vogel |
| You |
| Martin |
| Diamond |
| Joireman |
| Webber |
| Wendt |
| Davidsaver |
| Petrov |
| Finstrom |
| Cahill |
| Firebaugh |
| Goodwin |
| Kasley |
| McArthur |
| Franck |
| McClure |
| Voy |
| Marsh |
| Smedinghoff |

## Schedule

| ID | WBS | Task | Duration | Start | Finish | Predecessors | Total slack | Resources | Work |
| --- | --- | --- | --- | --- | --- | --- | --- | --- | --- |
| 1 | 1 | **ControlsX** | 53d? | 2008-08-20 | 2008-10-31 |  | 0d | Patrick | 2120h |
| 2 | 1.1 | **Requirements Document** | 10d | 2008-08-20 | 2008-09-02 |  | 0d |  |  |
| 3 | 1.1.1 | Gather Input from Customers | 5d | 2008-08-20 | 2008-08-26 |  | 0d |  |  |
| 4 | 1.1.2 | Refine Requirements | 5d | 2008-08-27 | 2008-09-02 | 3 | 0d |  |  |
| 6 | 1.2 | **Design** | 20d? | 2008-09-03 | 2008-09-30 | 2 | 0d |  | 688h |
| 7 | 1.2.1 | **Architecture** | 10d? | 2008-09-03 | 2008-09-16 |  | 0d |  | 408h |
| 8 | 1.2.1.1 | Matlab Interface | 1d? | 2008-09-03 | 2008-09-03 |  | 9d |  |  |
| 9 | 1.2.1.2 | Instrumentation Interface | 1d? | 2008-09-03 | 2008-09-03 |  | 9d | Voy | 8h |
| 10 | 1.2.1.3 | EPICs Interface | 10d | 2008-09-03 | 2008-09-16 |  | 0d | Hendricks; Nicklaus; Briegel | 240h |
| 11 | 1.2.1.4 | PID Loops | 10d | 2008-09-03 | 2008-09-16 |  | 0d | Nicklaus; Hendricks | 160h |
| 12 | 1.2.1.5 | Data Correlation | 10d | 2008-09-03 | 2008-09-16 |  | 0d |  |  |
| 13 | 1.2.2 | GUI | 10d | 2008-09-17 | 2008-09-30 | 7 | 0d | Petrov [10%]; Schumann [10%]; Marsh [10%] | 24h |
| 14 | 1.2.3 | Database | 10d | 2008-09-17 | 2008-09-30 | 7 | 0d | Finstrom | 80h |
| 15 | 1.2.4 | Data Acquisition | 10d | 2008-09-17 | 2008-09-30 | 7 | 0d |  |  |
| 16 | 1.2.5 | Data Logging | 10d | 2008-09-17 | 2008-09-30 | 7 | 0d | Cahill | 80h |
| 17 | 1.2.6 | Security | 10d | 2008-09-17 | 2008-09-30 | 7 | 0d |  |  |
| 18 | 1.2.7 | Protocol | 10d | 2008-09-17 | 2008-09-30 | 7 | 0d |  |  |
| 19 | 1.2.8 | Xclock | 10d | 2008-09-17 | 2008-09-30 | 7 | 0d | Vogel | 80h |
| 20 | 1.2.9 | Alarms | 10d | 2008-09-17 | 2008-09-30 | 7 | 0d |  |  |
| 21 | 1.2.10 | **Front Ends** | 1d? | 2008-09-17 | 2008-09-17 | 7 | 9d | Nicklaus | 16h |
| 22 | 1.2.10.1 | Acnet driver for EZCon Board | 1d? | 2008-09-17 | 2008-09-17 |  | 9d | Davidsaver | 8h |
| 23 | 1.3 | **Implementation** | 22d | 2008-10-01 | 2008-10-30 | 6 | 0d |  |  |
| 24 | 1.3.1 | GUI | 22d | 2008-10-01 | 2008-10-30 | 33, 13 | 0d |  |  |
| 25 | 1.3.2 | Database | 22d | 2008-10-01 | 2008-10-30 | 14 | 0d |  |  |
| 26 | 1.3.3 | Data Acquisition | 22d | 2008-10-01 | 2008-10-30 | 15 | 0d |  |  |
| 27 | 1.3.4 | Data Logging | 22d | 2008-10-01 | 2008-10-30 | 16 | 0d |  |  |
| 28 | 1.3.5 | Security | 22d | 2008-10-01 | 2008-10-30 | 17 | 0d |  |  |
| 29 | 1.3.6 | Protocol | 22d | 2008-10-01 | 2008-10-30 | 18 | 0d |  |  |
| 30 | 1.3.7 | Xclock | 22d | 2008-10-01 | 2008-10-30 | 19 | 0d |  |  |
| 31 | 1.3.8 | Alarms | 22d | 2008-10-01 | 2008-10-30 | 20 | 0d |  |  |

| ID | WBS | Task | Duration | Start | Finish | Predecessors | Total slack | Resources | Work |
| --- | --- | --- | --- | --- | --- | --- | --- | --- | --- |
| 33 | 1.4 | **Prototyping** | 30d | 2008-08-20 | 2008-09-30 |  | 0d |  | 960h |
| 34 | 1.4.1 | **GUI** | 30d | 2008-08-20 | 2008-09-30 |  | 0d |  | 480h |
| 35 | 1.4.1.1 | Synoptic Display Improvements | 30d | 2008-08-20 | 2008-09-30 |  | 0d | Petrov | 240h |
| 36 | 1.4.1.2 | Edm interface to ACNET | 30d | 2008-08-20 | 2008-09-30 |  | 0d | Schumann | 240h |
| 37 | 1.4.2 | UCD v6 | 30d | 2008-08-20 | 2008-09-30 |  | 0d | Briegel | 240h |
| 38 | 1.4.3 | Epics Interface | 30d | 2008-08-20 | 2008-09-30 |  | 0d | Nicklaus | 240h |
| 40 | 1.5 | **Installation** | 1d? | 2008-10-31 | 2008-10-31 | 23 | 0d |  | 48h |
| 41 | 1.5.1 | **HINS** | 1d? | 2008-10-31 | 2008-10-31 |  | 0d |  | 24h |
| 42 | 1.5.1.1 | install xClock | 1d? | 2008-10-31 | 2008-10-31 |  | 0d | Vogel | 8h |
| 43 | 1.5.1.2 | Install UCD | 1d? | 2008-10-31 | 2008-10-31 |  | 0d | Briegel | 8h |
| 44 | 1.5.1.3 | Install ACNET Console | 1d? | 2008-10-31 | 2008-10-31 |  | 0d | Smedinghoff | 8h |
| 45 | 1.5.1.4 | Install Datalogger | 1d? | 2008-10-31 | 2008-10-31 |  | 0d |  |  |
| 47 | 1.5.2 | **NML** | 1d? | 2008-10-31 | 2008-10-31 |  | 0d |  | 24h |
| 48 | 1.5.2.1 | Install xClock | 1d? | 2008-10-31 | 2008-10-31 |  | 0d | Vogel | 8h |
| 49 | 1.5.2.2 | Install UCD | 1d? | 2008-10-31 | 2008-10-31 |  | 0d | Briegel | 8h |
| 50 | 1.5.2.3 | Install ACNET Console | 1d? | 2008-10-31 | 2008-10-31 |  | 0d | Smedinghoff | 8h |
| 51 | 1.5.2.4 | install Data logger | 1d? | 2008-10-31 | 2008-10-31 |  | 0d |  |  |
